# upgrade_tiburon

Schedule from MS Project, 2005-01-03 to 2005-05-04, costs in $.
MBARI

## Calendars

- Standard: Mon-Fri 08:00-12:00, 13:00-17:00; Sat-Sun off.

## Resources

| Resource | Rate | Cost per use |
| --- | --- | --- |
| Engineer - Electrical-1 |  |  |
| Engineer - Mechanical-1 |  |  |
| Engineer - Machinist |  |  |
| Engineer - Associate |  |  |
| DMO - Tiburon Support |  |  |
| Foam |  | 150000 |
| Engineer - Electrical-2 |  |  |
| Engineer - Mechanical-2 |  |  |
| Crane base mods | 5000 | 5000 |
| Naval architect | 110 |  |
| Surface control system |  | 96000 |
| Tool sled componets |  | 20000 |
| Engineer - Software |  |  |
| Engineer - Support |  |  |
| Crane winch | 20000 | 15000 |
| Lift lines | 5000 | 5000 |
| CTD gear |  | 30000 |
| Belly pack |  | 15000 |
| Misc equipment for SSC |  | 5000 |
| VB spheres |  | 35000 |
| Camera hardware |  | 20000 |
| Science |  |  |
| DMO CTD tech |  |  |

## Schedule

| ID | WBS | Task | Duration | Start | Finish | Predecessors | Baseline start | Baseline finish | Baseline duration | Total slack | Free slack | Constraint | Resources | Work |
| --- | --- | --- | --- | --- | --- | --- | --- | --- | --- | --- | --- | --- | --- | --- |
| 1 | 1 | **Stage 1 - Preliminary Systems Engineering** | 87.43d | 2005-01-03 | 2005-05-04 |  | 2005-01-03 | 2005-02-07 | 26d? | 0d |  |  |  | 1180h |
| 2 | 1.1 | **Systems engineering (specifications review)** | 59.43d | 2005-01-24 | 2005-04-15 |  | 2005-01-03 | 2005-01-05 | 3d? | 0d |  |  |  | 736h |
| 3 | 1.1.1 | **Detailed design specification** | 49.43d | 2005-01-24 | 2005-04-01 |  | 2005-01-03 | 2005-01-05 | 3d? | 0d |  |  |  | 656h |
| 4 | 1.1.1.1 | **Power systems(top side)** | 7d | 2005-01-24 | 2005-02-01 |  | 2005-01-03 | 2005-01-04 | 2d? | 0d |  |  |  | 56h |
| 5 | 1.1.1.1.1 | Characterize existing Flyer power system | 3d | 2005-01-24 | 2005-01-26 |  | 2005-01-03 | 2005-01-04 | 2d | 0d |  | start no earlier than 2005-01-24 | Engineer - Electrical-1 | 24h |
| 6 | 1.1.1.1.2 | Block diagram of top side power system | 2d | 2005-01-27 | 2005-01-28 | 5 | 2005-01-03 | 2005-01-04 | 2d | 0d |  |  | Engineer - Associate | 16h |
| 7 | 1.1.1.1.3 | Requirements Document | 2d | 2005-01-31 | 2005-02-01 | 6 | 2005-01-03 | 2005-01-03 | 1d? | 0d |  |  | Engineer - Electrical-1 | 16h |
| 8 | 1.1.1.2 | **Power systems (subsea)** | 7d | 2005-02-02 | 2005-02-10 | 4 | 2005-01-03 | 2005-01-03 | 1d? | 0d |  |  |  | 56h |
| 9 | 1.1.1.2.1 | Subsea power requirements | 1d | 2005-02-02 | 2005-02-02 |  | 2005-01-03 | 2005-01-03 | 1d? | 0d |  |  | Engineer - Electrical-1 | 8h |
| 10 | 1.1.1.2.2 | Switching requirements | 1d | 2005-02-03 | 2005-02-03 | 9 |  |  |  | 0d |  |  | Engineer - Electrical-1 | 8h |
| 11 | 1.1.1.2.3 | GFM requirements | 1d | 2005-02-04 | 2005-02-04 | 10 |  |  |  | 0d |  |  | Engineer - Electrical-1 | 8h |
| 12 | 1.1.1.2.4 | Block diagram of subsea power system | 2d | 2005-02-07 | 2005-02-08 | 11 | 2005-01-03 | 2005-01-03 | 1d? | 0d |  |  | Engineer - Associate | 16h |
| 13 | 1.1.1.2.5 | Requirements Document | 2d | 2005-02-09 | 2005-02-10 | 12 | 2005-01-03 | 2005-01-03 | 1d? | 0d |  |  | Engineer - Electrical-1 | 16h |
| 14 | 1.1.1.3 | **Umbilical & slip ring** | 5d | 2005-02-11 | 2005-02-17 | 8 | 2005-01-03 | 2005-01-03 | 1d? | 0d |  |  |  | 40h |
| 15 | 1.1.1.3.1 | **Umbilical** | 2d | 2005-02-11 | 2005-02-14 |  |  |  |  | 0d |  |  |  | 16h |
| 16 | 1.1.1.3.1.1 | Umbilical termination j-box | 1d | 2005-02-11 | 2005-02-11 |  | 2005-01-03 | 2005-01-03 | 1d? | 0d |  |  | Engineer - Mechanical-1 | 8h |
| 17 | 1.1.1.3.1.2 | Power capacity review | 1d | 2005-02-14 | 2005-02-14 | 16 | 2005-01-03 | 2005-01-03 | 1d? | 0d |  |  | Engineer - Electrical-2 | 8h |
| 18 | 1.1.1.3.2 | **Slip rings** | 1d | 2005-02-15 | 2005-02-15 | 15 |  |  |  | 0d |  |  |  | 8h |
| 19 | 1.1.1.3.2.1 | Power & fiber upgrade requirements | 1d | 2005-02-15 | 2005-02-15 |  | 2005-01-03 | 2005-01-03 | 1d? | 0d |  |  | Engineer - Electrical-2 | 8h |
| 20 | 1.1.1.3.3 | Requirements Document | 2d | 2005-02-16 | 2005-02-17 | 19 | 2005-01-03 | 2005-01-03 | 1d? | 101.43d |  |  | Engineer - Electrical-2 | 16h |
| 21 | 1.1.1.4 | **Hydraulics & propulsion** | 3d | 2005-02-18 | 2005-02-22 | 14 | 2005-01-03 | 2005-01-05 | 3d | 46.43d | 0d |  |  | 24h |
| 22 | 1.1.1.4.1 | System requirements | 1d | 2005-02-18 | 2005-02-18 |  |  |  |  | 101.43d | 0d |  | Engineer - Mechanical-1 | 8h |
| 23 | 1.1.1.4.2 | Requirements Document | 2d | 2005-02-21 | 2005-02-22 | 22 | 2005-01-03 | 2005-01-05 | 3d | 101.43d |  |  | Engineer - Mechanical-1 | 16h |
| 24 | 1.1.1.5 | **Video & imaging** | 4d | 2005-02-23 | 2005-02-28 | 21 | 2005-01-03 | 2005-01-03 | 1d? | 46.43d |  |  |  | 80h |
| 25 | 1.1.1.5.1 | Current camera and lap box micro upgrade | 2d | 2005-02-23 | 2005-02-24 |  |  |  |  | 103.43d |  |  | Engineer - Electrical-1 | 16h |
| 26 | 1.1.1.5.2 | Pan & tilt requirements (review control and mech req.) | 2d | 2005-02-23 | 2005-02-24 |  | 2005-01-03 | 2005-01-03 | 1d? | 101.43d | 0d |  | Engineer - Mechanical-1; Engineer - Electrical-1 | 32h |
| 27 | 1.1.1.5.3 | Requirements Document | 2d | 2005-02-25 | 2005-02-28 | 26 | 2005-01-03 | 2005-01-03 | 1d? | 101.43d |  |  | Engineer - Electrical-1; Engineer - Mechanical-1 | 32h |

Notes:
- 3: Develop detailed design specifications for each sub task in order to get vendor RFQ
- 5: Take noise measurements to provide to vendor for RFQ
- 7: Requirements doc. is a summary of the western flyer power system including a noise char. to be provided to vendor for sign off.

| ID | WBS | Task | Duration | Start | Finish | Predecessors | Baseline start | Baseline finish | Baseline duration | Total slack | Resources | Work |
| --- | --- | --- | --- | --- | --- | --- | --- | --- | --- | --- | --- | --- |
| 28 | 1.1.1.6 | **Topside control systems** | 14d | 2005-02-16 | 2005-03-07 | 18 | 2005-01-03 | 2005-01-03 | 1d? | 0d |  | 128h |
| 29 | 1.1.1.6.1 | **Pilot console (joy stick, etc. integration)** | 1d | 2005-02-16 | 2005-02-16 |  | 2005-01-03 | 2005-01-03 | 1d? | 0d | Engineer - Electrical-1 | 16h |
| 30 | 1.1.1.6.1.1 | GUI display | 1d | 2005-02-16 | 2005-02-16 |  |  |  |  | 0d | DMO - Tiburon Support | 8h |
| 31 | 1.1.1.6.2 | **Science interface** | 2d | 2005-02-17 | 2005-02-18 | 30 | 2005-01-03 | 2005-01-03 | 1d? | 0d |  | 16h |
| 32 | 1.1.1.6.2.1 | Requirements Document | 2d | 2005-02-17 | 2005-02-18 |  | 2005-01-03 | 2005-01-03 | 1d? | 0d | Engineer - Electrical-1 | 16h |
| 33 | 1.1.1.6.3 | Nav Proc upgrade/replacement | 5d | 2005-02-21 | 2005-02-25 | 31 | 2005-01-03 | 2005-01-03 | 1d? | 0d | Engineer - Software | 40h |
| 34 | 1.1.1.6.4 | **Data systems (data logging)** | 4d | 2005-02-28 | 2005-03-03 | 33 | 2005-01-03 | 2005-01-03 | 1d? | 0d |  | 32h |
| 35 | 1.1.1.6.4.1 | Requirements Document | 4d | 2005-02-28 | 2005-03-03 |  | 2005-01-03 | 2005-01-03 | 1d? | 0d | Engineer - Software | 32h |
| 36 | 1.1.1.6.5 | Overlay & switching | 1d | 2005-02-16 | 2005-02-16 |  |  |  |  | 13d | Engineer - Electrical-1 | 8h |
| 37 | 1.1.1.6.6 | Block diagram of pilot console and control room | 2d | 2005-03-04 | 2005-03-07 | 34 | 2005-01-03 | 2005-01-03 | 1d? | 0d | Engineer - Associate | 16h |
| 38 | 1.1.1.7 | **Subsea control systems** | 8d | 2005-03-08 | 2005-03-17 | 28 | 2005-01-03 | 2005-01-03 | 1d? | 0d |  | 96h |
| 39 | 1.1.1.7.1 | Subsea control system requirements | 2d | 2005-03-08 | 2005-03-09 |  |  |  |  | 0d | Engineer - Electrical-1; DMO - Tiburon Support; Engineer - Mechanical-1 | 48h |
| 40 | 1.1.1.7.2 | Block diagram of subsea control system | 2d | 2005-03-10 | 2005-03-11 | 39 | 2005-01-03 | 2005-01-03 | 1d? | 0d | Engineer - Associate | 16h |
| 41 | 1.1.1.7.3 | Sensors & core equipment requirerments | 2d | 2005-03-14 | 2005-03-15 | 40 | 2005-01-03 | 2005-01-03 | 1d? | 0d | DMO - Tiburon Support | 16h |
| 42 | 1.1.1.7.4 | Subsea Requirements Document | 2d | 2005-03-16 | 2005-03-17 | 41 | 2005-01-03 | 2005-01-03 | 1d? | 0d | Engineer - Electrical-1 | 16h |
| 43 | 1.1.1.8 | **Tool sled controller requirements** | 10.43d | 2005-03-18 | 2005-04-01 | 38 | 2005-01-03 | 2005-01-03 | 1d? | 0d |  | 176h |
| 44 | 1.1.1.8.1 | Video, data and I/O | 3.43d | 2005-03-18 | 2005-03-23 |  | 2005-01-03 | 2005-01-03 | 1d? | 0d | Engineer - Electrical-1; DMO - Tiburon Support; Engineer - Associate; Engineer - Software [50%] | 96h |
| 45 | 1.1.1.8.2 | Hydraulics | 1d | 2005-03-23 | 2005-03-24 | 44 | 2005-01-03 | 2005-01-03 | 1d? | 0d | Engineer - Mechanical-1; DMO - Tiburon Support | 16h |
| 46 | 1.1.1.8.3 | Power, switching and GFM | 2d | 2005-03-24 | 2005-03-28 | 45 | 2005-01-03 | 2005-01-03 | 1d? | 0d | Engineer - Electrical-1; DMO - Tiburon Support | 32h |
| 47 | 1.1.1.8.4 | Block diagram of tool sled controller | 2d | 2005-03-28 | 2005-03-30 | 46 | 2005-01-03 | 2005-01-03 | 1d? | 0d | Engineer - Associate | 16h |
| 48 | 1.1.1.8.5 | Requirements Document | 2d | 2005-03-30 | 2005-04-01 | 47 | 2005-01-03 | 2005-01-03 | 1d? | 0d | Engineer - Electrical-1 | 16h |
| 49 | 1.1.2 | Electro/hydraulic systems specification PDR | 10d | 2005-04-01 | 2005-04-15 | 43 | 2005-01-03 | 2005-01-03 | 1d? | 68d | Engineer - Electrical-1 [25%]; Engineer - Mechanical-1 [25%]; DMO - Tiburon Support [25%]; Engineer - Software [25%] | 80h |
| 50 | 1.2 | **Frame, buoyancy & payload requirements review** | 23d | 2005-04-01 | 2005-05-04 | 43 | 2005-01-03 | 2005-01-07 | 5d? | 0d |  | 224h |
| 51 | 1.2.1 | **Frame requirements** | 4d | 2005-04-01 | 2005-04-07 |  | 2005-01-03 | 2005-01-03 | 1d? | 0d |  | 32h |
| 52 | 1.2.1.1 | Equipment mounts, brackets, etc. | 1d | 2005-04-01 | 2005-04-04 |  | 2005-01-03 | 2005-01-03 | 1d? | 0d | Engineer - Mechanical-1 | 8h |
| 53 | 1.2.1.2 | Latch requirements | 1d | 2005-04-04 | 2005-04-05 | 52 | 2005-01-03 | 2005-01-03 | 1d? | 0d | Engineer - Mechanical-1 | 8h |
| 54 | 1.2.1.3 | Requirements document | 2d | 2005-04-05 | 2005-04-07 | 53 | 2005-01-03 | 2005-01-03 | 1d? | 0d | Engineer - Mechanical-1 | 16h |

| ID | WBS | Task | Type | Duration | Start | Finish | Predecessors | Baseline start | Baseline finish | Baseline duration | Total slack | Free slack | Resources | Work | Cost |
| --- | --- | --- | --- | --- | --- | --- | --- | --- | --- | --- | --- | --- | --- | --- | --- |
| 55 | 1.2.2 | **VB requirements** |  | 9d | 2005-04-07 | 2005-04-20 | 51 | 2005-01-03 | 2005-01-07 | 5d | 0d |  |  | 72h |  |
| 56 | 1.2.2.1 | Pump review |  | 4d | 2005-04-07 | 2005-04-13 |  | 2005-01-03 | 2005-01-07 | 5d | 0d |  | Engineer - Mechanical-1 | 32h |  |
| 57 | 1.2.2.2 | Sphere review |  | 3d | 2005-04-13 | 2005-04-18 | 56 | 2005-01-03 | 2005-01-07 | 5d | 0d |  | Engineer - Mechanical-1 | 24h |  |
| 58 | 1.2.2.3 | Block diagram |  | 2d | 2005-04-18 | 2005-04-20 | 57 |  |  |  | 0d |  | Engineer - Associate | 16h |  |
| 59 | 1.2.3 | **Payload requirements** |  | 10d | 2005-04-20 | 2005-05-04 | 55 | 2005-01-03 | 2005-01-03 | 1d? | 0d |  |  | 96h |  |
| 60 | 1.2.3.1 | **Weights (in air/water)** |  | 10d | 2005-04-20 | 2005-05-04 |  | 2005-01-03 | 2005-01-03 | 1d? | 0d |  |  | 80h |  |
| 61 | 1.2.3.1.1 | Spread sheet for weights (in air/water |  | 10d | 2005-04-20 | 2005-05-04 |  | 2005-01-03 | 2005-01-03 | 1d? | 0d |  | Engineer - Mechanical-1 | 80h |  |
| 62 | 1.2.3.2 | Foam pack |  | 2d | 2005-04-20 | 2005-04-22 |  |  |  |  | 8d |  | Engineer - Mechanical-1 | 16h |  |
| 63 | 1.2.4 | Frame, buoyancy & payload PDR |  | 1d | 2005-04-01 | 2005-04-04 |  | 2005-01-03 | 2005-01-03 | 1d? | 22d |  | Engineer - Mechanical-1; DMO - Tiburon Support | 16h |  |
| 64 | 1.2.5 | **Crane base modifications** |  | 1d | 2005-04-01 | 2005-04-04 |  |  |  |  | 22d |  |  | 8h |  |
| 65 | 1.2.5.1 | Requirements Document |  | 1d | 2005-04-01 | 2005-04-04 |  | 2005-01-03 | 2005-01-03 | 1d? | 22d |  | Engineer - Mechanical-1 | 8h |  |
| 66 | 1.3 | Detailed specifications document |  | 5d | 2005-01-03 | 2005-01-07 |  | 2005-01-03 | 2005-01-03 | 1d? | 29.43d | 0d | Engineer - Electrical-1; Engineer - Mechanical-1; DMO - Tiburon Support; Engineer - Software | 160h |  |
| 67 | 1.4 | System engineering complete | milestone | 0d | 2005-01-07 | 2005-01-07 | 66 |  |  |  | 29.43d | 0d |  |  |  |
| 68 | 1.5 | Request for RFQ |  | 4w | 2005-01-10 | 2005-02-04 | 67 | 2005-01-04 | 2005-01-24 | 3w | 29.43d | 0d |  |  |  |
| 69 | 1.6 | Review RFQ | milestone | 1w | 2005-02-07 | 2005-02-11 | 68 | 2005-01-25 | 2005-02-07 | 2w | 29.43d | 0d | Engineer - Electrical-1 [50%]; Engineer - Mechanical-1 [50%]; DMO - Tiburon Support [25%]; Engineer - Software [25%] | 60h |  |
| 70 | 2 | **Stage 2 - Design** |  | 28d | 2005-02-14 | 2005-03-23 | 69 | 2005-02-08 | 2005-02-21 | 10d? | 29.43d |  |  | 963.04h | 1,760 |
| 71 | 2.1 | **Surface control systems** |  | 10d | 2005-02-14 | 2005-02-25 |  | 2005-02-08 | 2005-02-08 | 1d? | 43.43d |  |  | 250h |  |
| 72 | 2.1.1 | Nav Proc upgrade |  | 5d | 2005-02-14 | 2005-02-18 |  | 2005-02-08 | 2005-02-08 | 1d? | 43.43d | 0d | Engineer - Software | 40h |  |
| 73 | 2.1.2 | Data systems (logging) |  | 5d | 2005-02-21 | 2005-02-25 | 72 | 2005-02-08 | 2005-02-08 | 1d? | 43.43d | 0d | Engineer - Software | 40h |  |
| 74 | 2.1.3 | CTD Display |  | 3d | 2005-02-14 | 2005-02-16 |  |  |  |  | 54.43d |  | Engineer - Software; DMO CTD tech | 48h |  |
| 75 | 2.1.4 | Advanced control systems |  | 2d | 2005-02-14 | 2005-02-15 |  |  |  |  | 55.43d |  | Engineer - Support | 16h |  |
| 76 | 2.1.5 | Pilot console (joy sticks, etc.) |  | 5d | 2005-02-14 | 2005-02-18 |  |  |  |  | 52.43d |  | Engineer - Electrical-1 | 40h |  |
| 77 | 2.1.6 | CDR |  | 3d | 2005-02-14 | 2005-02-16 |  |  |  |  | 54.43d |  | Engineer - Electrical-1; Engineer - Mechanical-1 [50%]; Engineer - Software; DMO - Tiburon Support [25%] | 66h |  |
| 78 | 2.2 | **Tool sled controller** |  | 4d | 2005-02-28 | 2005-03-03 | 73 | 2005-02-08 | 2005-02-08 | 1d? | 43.43d |  |  | 164h |  |
| 79 | 2.2.1 | **Mux, power, I/O systems** |  | 4d | 2005-02-28 | 2005-03-03 |  |  |  |  | 43.43d |  |  | 128h |  |
| 80 | 2.2.1.1 | Housing & packaging |  | 4d | 2005-02-28 | 2005-03-03 |  |  |  |  | 43.43d |  | Engineer - Mechanical-1; DMO - Tiburon Support | 64h |  |
| 81 | 2.2.1.2 | Electrical design |  | 4d | 2005-02-28 | 2005-03-03 |  |  |  |  | 43.43d |  | Engineer - Electrical-1; DMO - Tiburon Support | 64h |  |
| 82 | 2.2.2 | CDR |  | 2d | 2005-02-28 | 2005-03-01 |  |  |  |  | 45.43d |  | Engineer - Electrical-1; Engineer - Mechanical-1; DMO - Tiburon Support [25%] | 36h |  |

| ID | WBS | Task | Type | Duration | Start | Finish | Predecessors | Baseline start | Baseline finish | Baseline duration | Total slack | Free slack | Resources | Work | Cost |
| --- | --- | --- | --- | --- | --- | --- | --- | --- | --- | --- | --- | --- | --- | --- | --- |
| 83 | 2.3 | **Camera & viewing systems** |  | 14.5d | 2005-02-14 | 2005-03-04 |  |  |  |  | 42.93d |  |  | 221.04h |  |
| 84 | 2.3.1 | Camera, pan & tilt systems |  | 10d | 2005-02-14 | 2005-02-25 |  |  |  |  | 47.43d |  | Engineer - Mechanical-1 [50%]; Engineer - Electrical-1; DMO - Tiburon Support [25%] | 140h |  |
| 85 | 2.3.2 | Lap boxes |  | 1.5w | 2005-02-14 | 2005-02-23 |  |  |  |  | 42.93d | 0d | Engineer - Electrical-1; Engineer - Mechanical-1 [50%]; DMO - Tiburon Support [25%]; Science [10%] | 34.6h |  |
| 86 | 2.3.3 | Iview control |  | 1w | 2005-02-23 | 2005-03-02 | 85 |  |  |  | 42.93d | 0d | Engineer - Software; DMO - Tiburon Support [25%]; Engineer - Electrical-1 [25%] | 14.44h |  |
| 87 | 2.3.4 | CDR |  | 2d | 2005-03-02 | 2005-03-04 | 86 |  |  |  | 42.93d |  | Engineer - Electrical-1; Engineer - Software | 32h |  |
| 88 | 2.4 | **Frame, buoyancy & payload** |  | 28d | 2005-02-14 | 2005-03-23 |  | 2005-02-08 | 2005-02-21 | 10d? | 29.43d |  |  | 328h | 1,760 |
| 89 | 2.4.1 | **Frame design** |  | 28d | 2005-02-14 | 2005-03-23 |  | 2005-02-08 | 2005-02-21 | 10d? | 29.43d |  |  | 224h |  |
| 90 | 2.4.1.1 | Core frame design |  | 2w | 2005-02-14 | 2005-02-25 |  | 2005-02-08 | 2005-02-21 | 2w | 29.43d | 0d | Engineer - Mechanical-1 | 80h |  |
| 91 | 2.4.1.2 | Vehicle latch design |  | 1w | 2005-02-28 | 2005-03-04 | 90 | 2005-02-08 | 2005-02-14 | 1w | 29.43d | 0d | Engineer - Mechanical-1 | 40h |  |
| 92 | 2.4.1.3 | Umbilical termination j-box |  | 1w | 2005-03-07 | 2005-03-11 | 91 | 2005-02-08 | 2005-02-14 | 1w | 29.43d | 0d | Engineer - Mechanical-1 | 40h |  |
| 93 | 2.4.1.4 | Brackets, mounts and hardware |  | 5d | 2005-03-14 | 2005-03-18 | 92 | 2005-02-08 | 2005-02-08 | 1d? | 29.43d | 0d | Engineer - Mechanical-1 | 40h |  |
| 94 | 2.4.1.5 | 3D Model subsystems |  | 3d | 2005-03-21 | 2005-03-23 | 93 |  |  |  | 29.43d |  | Engineer - Mechanical-1 | 24h |  |
| 95 | 2.4.2 | **VB system design** |  | 2d | 2005-02-14 | 2005-02-15 |  | 2005-02-08 | 2005-02-08 | 1d? | 55.43d |  |  | 24h |  |
| 96 | 2.4.2.1 | System design |  | 2d | 2005-02-14 | 2005-02-15 |  |  |  |  | 55.43d |  | Engineer - Mechanical-1 | 16h |  |
| 97 | 2.4.2.2 | Level feed back |  | 1d | 2005-02-14 | 2005-02-14 |  |  |  |  | 56.43d |  | Engineer - Electrical-1 | 8h |  |
| 98 | 2.4.3 | **Foam pack** |  | 5d | 2005-02-14 | 2005-02-18 |  | 2005-02-08 | 2005-02-08 | 1d? | 52.43d |  |  | 40h |  |
| 99 | 2.4.3.1 | Foam pack design |  | 1w | 2005-02-14 | 2005-02-18 |  | 2005-02-08 | 2005-02-08 | 1d? | 52.43d |  | Engineer - Mechanical-1 | 40h |  |
| 100 | 2.4.4 | **Crane base modifications** |  | 2d | 2005-02-14 | 2005-02-15 |  | 2005-01-03 | 2005-01-03 | 1d? | 55.43d |  |  | 16h | 1,760 |
| 101 | 2.4.4.1 | Out side services |  | 2d | 2005-02-14 | 2005-02-15 |  |  |  |  | 55.43d |  | Naval architect | 16h | 1,760 |
| 102 | 2.4.5 | CDR |  | 2d | 2005-02-14 | 2005-02-15 |  |  |  |  | 55.43d |  | Engineer - Mechanical-1 | 16h |  |
| 103 | 2.4.6 | RFQ for foam pack |  | 1d | 2005-02-14 | 2005-02-14 |  |  |  |  | 56.43d |  | Engineer - Mechanical-1 | 8h |  |
| 104 | 3 | System Design complete | milestone | 0d | 2005-01-03 | 2005-01-03 |  |  |  |  | 87.43d |  |  |  |  |
| 105 | 4 | **Stage 3 - 1st year development** |  | 15d | 2005-01-03 | 2005-01-21 |  |  |  |  | 72.43d |  |  | 925.72h | 391,000 |
| 106 | 4.1 | **Surface control system** |  | 10d | 2005-01-03 | 2005-01-14 |  |  |  |  | 77.43d |  |  | 101.72h | 111,000 |
| 107 | 4.1.1 | Purchase Surface control system | milestone | 0d | 2005-01-03 | 2005-01-03 |  |  |  |  | 87.43d |  | Surface control system |  | 96,000 |
| 108 | 4.1.2 | Belly pack controls (purchase) | milestone | 0d | 2005-01-03 | 2005-01-03 |  |  |  |  | 87.43d |  | Belly pack |  | 15,000 |
| 109 | 4.1.3 | Interface & test data systems |  | 4d | 2005-01-03 | 2005-01-06 |  |  |  |  | 83.43d |  | Engineer - Electrical-1 [50%]; Engineer - Software; DMO - Tiburon Support [10%]; DMO CTD tech [10%] | 21.72h |  |
| 110 | 4.1.4 | Advanced control systems |  | 2w | 2005-01-03 | 2005-01-14 |  |  |  |  | 77.43d |  | Engineer - Support | 80h |  |

| ID | WBS | Task | Type | Duration | Start | Finish | Total slack | Resources | Work | Cost |
| --- | --- | --- | --- | --- | --- | --- | --- | --- | --- | --- |
| 111 | 4.2 | **Toolsled controller** |  | 5d | 2005-01-03 | 2005-01-07 | 82.43d |  | 80h | 20,000 |
| 112 | 4.2.1 | Purchase tool sled controller | milestone | 0d | 2005-01-03 | 2005-01-03 | 87.43d | Tool sled componets |  | 20,000 |
| 113 | 4.2.2 | integrate tool sled controller |  | 1w | 2005-01-03 | 2005-01-07 | 82.43d | Engineer - Associate; Engineer - Machinist | 80h |  |
| 114 | 4.3 | **Camera & viewing** |  | 15d | 2005-01-03 | 2005-01-21 | 72.43d |  | 528h | 20,000 |
| 115 | 4.3.1 | Purchase hardware |  | 1d | 2005-01-03 | 2005-01-03 | 86.43d | Engineer - Electrical-1; Camera hardware | 8h | 20,000 |
| 116 | 4.3.2 | Lap box interface |  | 2w | 2005-01-03 | 2005-01-14 | 77.43d | Engineer - Electrical-1; Engineer - Software; DMO - Tiburon Support | 240h |  |
| 117 | 4.3.3 | Modified IVIEW control system |  | 3w | 2005-01-03 | 2005-01-21 | 72.43d | Engineer - Software | 120h |  |
| 118 | 4.3.4 | Integration & test |  | 2w | 2005-01-03 | 2005-01-14 | 77.43d | Engineer - Electrical-1; Engineer - Machinist | 160h |  |
| 119 | 4.4 | **Frame, buoyancy & payload** |  | 5d | 2005-01-03 | 2005-01-07 | 82.43d |  | 216h | 240,000 |
| 120 | 4.4.1 | Final frame & foam pack design |  | 2d | 2005-01-03 | 2005-01-04 | 85.43d | Engineer - Mechanical-1 | 16h |  |
| 121 | 4.4.2 | Purchase VB spheres |  | 1d | 2005-01-03 | 2005-01-03 | 86.43d | VB spheres; Engineer - Mechanical-1 | 8h | 35,000 |
| 122 | 4.4.3 | Fabricate & test VB system |  | 1w | 2005-01-03 | 2005-01-07 | 82.43d | Engineer - Mechanical-1; Engineer - Machinist; DMO - Tiburon Support | 120h |  |
| 123 | 4.4.4 | Purchase foam |  | 1d | 2005-01-03 | 2005-01-03 | 86.43d | Foam; Engineer - Mechanical-1 | 8h | 150,000 |
| 124 | 4.4.5 | **Crane base modifications** |  | 5d | 2005-01-03 | 2005-01-07 | 82.43d |  | 64h | 55,000 |
| 125 | 4.4.5.1 | Purchase materials for mods |  | 1d | 2005-01-03 | 2005-01-03 | 86.43d | Crane base mods; Engineer - Mechanical-1 | 8h | 10,000 |
| 126 | 4.4.5.2 | Purchase winch |  | 1d | 2005-01-03 | 2005-01-03 | 86.43d | Crane winch; Engineer - Mechanical-1 | 8h | 35,000 |
| 127 | 4.4.5.3 | Purchase lift lines |  | 1d | 2005-01-03 | 2005-01-03 | 86.43d | Lift lines; Engineer - Mechanical-1 | 8h | 10,000 |
| 128 | 4.4.5.4 | Perform modifications |  | 1w | 2005-01-03 | 2005-01-07 | 82.43d | Engineer - Machinist | 40h |  |
| 129 | 5 | 1st year development complete | milestone | 0d | 2005-01-03 | 2005-01-03 | 87.43d |  |  |  |
