# upgrade_tiburon_rev2

Schedule from MS Project, 2005-01-24 to 2005-11-24, costs in $.
Tiburon II
MBARI
System and sub system system engineering, design and developement

## Calendars

- Standard: Mon-Fri 08:00-12:00, 13:00-17:00; Sat-Sun off.

## Resources

| Resource | Rate | Cost per use |
| --- | --- | --- |
| Engineer - Electrical-1 |  |  |
| Engineer - Mechanical-1 |  |  |
| Engineer - Machinist |  |  |
| Engineer - Associate |  |  |
| DMO - Tiburon Support |  |  |
| Foam |  | 150000 |
| Crane base mods | 5000 | 5000 |
| Naval architect | 110 |  |
| Surface control system |  | 96000 |
| Tool sled componets |  | 20000 |
| Engineer - Software |  |  |
| Engineer - Support |  |  |
| Crane winch | 20000 | 15000 |
| Lift lines | 5000 | 5000 |
| CTD gear |  | 30000 |
| Belly pack |  | 15000 |
| Misc equipment for SSC |  | 5000 |
| VB spheres |  | 35000 |
| Camera hardware |  | 20000 |
| Science |  |  |
| DMO CTD tech |  |  |
| Travel to UK |  |  |

## Schedule

| ID | WBS | Task | Duration | Start | Finish | Predecessors | Baseline start | Baseline finish | Baseline duration | Total slack | Free slack | Constraint | Resources | Work |
| --- | --- | --- | --- | --- | --- | --- | --- | --- | --- | --- | --- | --- | --- | --- |
| 1 | 1 | **Stage 1 - Preliminary Systems Engineering** | 108d | 2005-01-24 | 2005-06-22 |  | 2005-01-03 | 2005-02-07 | 26d? | 0d |  |  |  | 1340h |
| 2 | 1.1 | **Systems engineering (specifications review)** | 56d | 2005-01-24 | 2005-04-11 |  | 2005-01-03 | 2005-01-05 | 3d? | 38d |  |  |  | 896h |
| 3 | 1.1.1 | **Detailed design specification** | 46d | 2005-01-24 | 2005-03-28 |  | 2005-01-03 | 2005-01-05 | 3d? | 38d |  |  |  | 816h |
| 4 | 1.1.1.1 | **Power systems(top side)** | 5d | 2005-01-24 | 2005-01-28 |  | 2005-01-03 | 2005-01-04 | 2d? | 94d | 0d |  |  | 56h |
| 5 | 1.1.1.1.1 | Characterize existing Flyer power system | 3d | 2005-01-24 | 2005-01-26 |  | 2005-01-03 | 2005-01-04 | 2d | 4d | 0d | start no earlier than 2005-01-24 | Engineer - Electrical-1 | 24h |
| 6 | 1.1.1.1.2 | Block diagram of top side power system | 2d | 2005-01-27 | 2005-01-28 | 5 | 2005-01-03 | 2005-01-04 | 2d | 4d | 0d |  | Engineer - Associate | 16h |
| 7 | 1.1.1.1.3 | Requirements Document | 2d | 2005-01-27 | 2005-01-28 | 6SS | 2005-01-03 | 2005-01-03 | 1d? | 4d |  |  | Engineer - Electrical-1 | 16h |
| 8 | 1.1.1.2 | **Power systems (subsea)** | 5d | 2005-01-31 | 2005-02-04 | 4 | 2005-01-03 | 2005-01-03 | 1d? | 94d | 0d |  |  | 56h |
| 9 | 1.1.1.2.1 | Subsea power requirements | 1d | 2005-01-31 | 2005-01-31 | 12SS | 2005-01-03 | 2005-01-03 | 1d? | 4d | 0d |  | Engineer - Electrical-1 | 8h |
| 10 | 1.1.1.2.2 | Switching requirements | 1d | 2005-02-01 | 2005-02-01 | 9 | 2005-02-01 | 2005-02-01 | 1d | 4d | 0d |  | Engineer - Electrical-1 | 8h |
| 11 | 1.1.1.2.3 | GFM requirements | 1d | 2005-02-02 | 2005-02-02 | 10 | 2005-02-02 | 2005-02-02 | 1d | 4d | 0d |  | Engineer - Electrical-1 | 8h |
| 12 | 1.1.1.2.4 | Block diagram of subsea power system | 2d | 2005-01-31 | 2005-02-01 |  | 2005-01-03 | 2005-01-03 | 1d? | 4d | 0d | start no earlier than 2005-01-31 | Engineer - Associate | 16h |
| 13 | 1.1.1.2.5 | Requirements Document | 2d | 2005-02-03 | 2005-02-04 | 11 | 2005-01-03 | 2005-01-03 | 1d? | 4d |  | start no earlier than 2005-02-03 | Engineer - Electrical-1 | 16h |
| 14 | 1.1.1.3 | **Umbilical & slip ring** | 4d | 2005-02-07 | 2005-02-10 | 8 | 2005-01-03 | 2005-01-03 | 1d? | 94d | 0d |  |  | 40h |
| 15 | 1.1.1.3.1 | **Umbilical** | 1d | 2005-02-07 | 2005-02-07 |  | 2005-02-07 | 2005-02-07 | 1d | 94d | 0d |  |  | 16h |
| 16 | 1.1.1.3.1.1 | Umbilical termination j-box | 1d | 2005-02-07 | 2005-02-07 |  | 2005-01-03 | 2005-01-03 | 1d? | 4d |  |  | Engineer - Mechanical-1 | 8h |
| 17 | 1.1.1.3.1.2 | Power capacity review | 1d | 2005-02-07 | 2005-02-07 |  | 2005-01-03 | 2005-01-03 | 1d? | 4d |  | start no earlier than 2005-02-06 | Engineer - Electrical-1 | 8h |
| 18 | 1.1.1.3.2 | **Slip rings** | 1d | 2005-02-08 | 2005-02-08 | 15 | 2005-02-08 | 2005-02-08 | 1d | 94d |  |  |  | 8h |
| 19 | 1.1.1.3.2.1 | Power & fiber upgrade requirements | 1d | 2005-02-08 | 2005-02-08 |  | 2005-01-03 | 2005-01-03 | 1d? | 4d | 0d |  | Engineer - Electrical-1 | 8h |
| 20 | 1.1.1.3.3 | Requirements Document | 2d | 2005-02-09 | 2005-02-10 | 19 | 2005-01-03 | 2005-01-03 | 1d? | 4d |  |  | Engineer - Electrical-1 | 16h |
| 21 | 1.1.1.4 | **Hydraulics & propulsion** | 3d | 2005-02-08 | 2005-02-10 | 14SS+1d | 2005-01-03 | 2005-01-05 | 3d | 27d | 0d |  |  | 24h |
| 22 | 1.1.1.4.1 | System requirements | 1d | 2005-02-08 | 2005-02-08 |  | 2005-02-08 | 2005-02-08 | 1d | 27d | 0d | start no earlier than 2005-02-07 | Engineer - Mechanical-1 | 8h |
| 23 | 1.1.1.4.2 | Requirements Document | 2d | 2005-02-09 | 2005-02-10 | 22 | 2005-01-03 | 2005-01-05 | 3d | 27d |  |  | Engineer - Mechanical-1 | 16h |
| 24 | 1.1.1.5 | **Video & imaging** | 10d | 2005-02-11 | 2005-02-24 | 21 | 2005-01-03 | 2005-01-03 | 1d? | 27d | 0d |  |  | 240h |
| 25 | 1.1.1.5.1 | Current camera and lap box micro upgrade | 2d | 2005-02-17 | 2005-02-18 | 27 | 2005-02-17 | 2005-02-18 | 2d | 31d |  | start no earlier than 2005-02-14 | Engineer - Electrical-1 | 16h |
| 26 | 1.1.1.5.2 | Pan & tilt requirements (review control and mech req.) | 2d | 2005-02-11 | 2005-02-14 |  | 2005-01-03 | 2005-01-03 | 1d? | 31d | 0d |  | Engineer - Mechanical-1; Engineer - Electrical-1 | 32h |
| 27 | 1.1.1.5.3 | Requirements Document | 2d | 2005-02-15 | 2005-02-16 | 26 | 2005-01-03 | 2005-01-03 | 1d? | 31d | 0d |  | Engineer - Electrical-1; Engineer - Mechanical-1 | 32h |
| 28 | 1.1.1.5.4 | IVEW | 2w | 2005-02-11 | 2005-02-24 |  | 2005-02-11 | 2005-02-24 | 2w | 27d |  |  | Engineer - Electrical-1; Engineer - Software | 160h |

Notes:
- 3: Develop detailed design specifications for each sub task in order to get vendor RFQ
- 5: Take noise measurements of Western Flyer power to provide to vendor for RFQ
- 7: Requirements doc. is a summary of the western flyer power system including a noise char. to be provided to vendor for sign off.
- 9: Detailed list of required bus voltages, regulation and power requirements for ROV
- 10: Detail switching requirements for bus voltages
- 11: Detail level of GFM for power systems

| ID | WBS | Task | Duration | Start | Finish | Predecessors | Baseline start | Baseline finish | Baseline duration | Total slack | Free slack | Constraint | Resources | Work |
| --- | --- | --- | --- | --- | --- | --- | --- | --- | --- | --- | --- | --- | --- | --- |
| 29 | 1.1.1.6 | **Topside control systems** | 9d | 2005-02-25 | 2005-03-09 | 24 | 2005-01-03 | 2005-01-03 | 1d? | 27d | 0d |  |  | 128h |
| 30 | 1.1.1.6.1 | **Pilot console (joy stick, etc. integration)** | 1d | 2005-02-25 | 2005-02-25 |  | 2005-01-03 | 2005-01-03 | 1d? | 35d | 0d |  | Engineer - Electrical-1 | 16h |
| 31 | 1.1.1.6.1.1 | GUI display | 1d | 2005-02-25 | 2005-02-25 |  | 2005-02-25 | 2005-02-25 | 1d | 35d |  |  | DMO - Tiburon Support | 8h |
| 32 | 1.1.1.6.2 | **Science interface** | 2d | 2005-02-25 | 2005-02-28 | 30SS | 2005-01-03 | 2005-01-03 | 1d? | 34d |  |  |  | 16h |
| 33 | 1.1.1.6.2.1 | Requirements Document | 2d | 2005-02-25 | 2005-02-28 |  | 2005-01-03 | 2005-01-03 | 1d? | 34d |  | start no earlier than 2005-02-20 | Engineer - Electrical-1 | 16h |
| 34 | 1.1.1.6.3 | Nav Proc upgrade/replacement | 5d | 2005-02-25 | 2005-03-03 |  | 2005-01-03 | 2005-01-03 | 1d? | 27d | 0d |  | Engineer - Software | 40h |
| 35 | 1.1.1.6.4 | **Data systems (data logging)** | 4d | 2005-03-04 | 2005-03-09 | 34 | 2005-01-03 | 2005-01-03 | 1d? | 27d |  |  |  | 32h |
| 36 | 1.1.1.6.4.1 | Requirements Document | 4d | 2005-03-04 | 2005-03-09 |  | 2005-01-03 | 2005-01-03 | 1d? | 27d |  |  | Engineer - Software | 32h |
| 37 | 1.1.1.6.5 | Overlay & switching | 1d | 2005-02-28 | 2005-02-28 | 35 | 2005-02-28 | 2005-02-28 | 1d | 34d |  | start no earlier than 2005-02-28 | Engineer - Electrical-1 | 8h |
| 38 | 1.1.1.6.6 | Block diagram of pilot console and control room | 2d | 2005-02-28 | 2005-03-01 |  | 2005-01-03 | 2005-01-03 | 1d? | 33d |  | start no earlier than 2005-02-28 | Engineer - Associate | 16h |
| 39 | 1.1.1.7 | **Subsea control systems** | 6d | 2005-03-10 | 2005-03-17 | 29 | 2005-01-03 | 2005-01-03 | 1d? | 27d | 0d |  |  | 96h |
| 40 | 1.1.1.7.1 | Subsea control system requirements | 2d | 2005-03-10 | 2005-03-11 |  | 2005-03-10 | 2005-03-11 | 2d | 27d | 0d |  | Engineer - Electrical-1; DMO - Tiburon Support; Engineer - Mechanical-1 | 48h |
| 41 | 1.1.1.7.2 | Block diagram of subsea control system | 2d | 2005-03-10 | 2005-03-11 | 40SS | 2005-01-03 | 2005-01-03 | 1d? | 27d | 0d |  | Engineer - Associate | 16h |
| 42 | 1.1.1.7.3 | Sensors & core equipment requirerments | 2d | 2005-03-14 | 2005-03-15 | 41 | 2005-01-03 | 2005-01-03 | 1d? | 27d | 0d |  | DMO - Tiburon Support | 16h |
| 43 | 1.1.1.7.4 | Subsea Requirements Document | 2d | 2005-03-16 | 2005-03-17 | 42 | 2005-01-03 | 2005-01-03 | 1d? | 27d |  |  | Engineer - Electrical-1 | 16h |
| 44 | 1.1.1.8 | **Tool sled controller requirements** | 7d | 2005-03-18 | 2005-03-28 | 39 | 2005-01-03 | 2005-01-03 | 1d? | 27d | 0d |  |  | 176h |
| 45 | 1.1.1.8.1 | Video, data and I/O | 3.43d | 2005-03-18 | 2005-03-23 |  | 2005-01-03 | 2005-01-03 | 1d? | 27d | 0d |  | Engineer - Electrical-1; DMO - Tiburon Support; Engineer - Associate; Engineer - Software [50%] | 96h |
| 46 | 1.1.1.8.2 | Hydraulics | 1d | 2005-03-18 | 2005-03-18 | 45SS | 2005-01-03 | 2005-01-03 | 1d? | 27d | 0d |  | Engineer - Mechanical-1; DMO - Tiburon Support | 16h |
| 47 | 1.1.1.8.3 | Power, switching and GFM | 2d | 2005-03-21 | 2005-03-22 | 46 | 2005-01-03 | 2005-01-03 | 1d? | 27d | 0d |  | Engineer - Electrical-1; DMO - Tiburon Support | 32h |
| 48 | 1.1.1.8.4 | Block diagram of tool sled controller | 2d | 2005-03-23 | 2005-03-24 | 47 | 2005-01-03 | 2005-01-03 | 1d? | 27d | 0d |  | Engineer - Associate | 16h |
| 49 | 1.1.1.8.5 | Requirements Document | 2d | 2005-03-25 | 2005-03-28 | 48 | 2005-01-03 | 2005-01-03 | 1d? | 27d |  |  | Engineer - Electrical-1 | 16h |
| 50 | 1.1.2 | Electro/hydraulic systems specification PDR | 10d | 2005-03-29 | 2005-04-11 | 44 | 2005-01-03 | 2005-01-03 | 1d? | 52d |  |  | Engineer - Electrical-1 [25%]; Engineer - Mechanical-1 [25%]; DMO - Tiburon Support [25%]; Engineer - Software [25%] | 80h |
| 51 | 1.2 | **Frame, buoyancy & payload requirements review** | 30d | 2005-04-20 | 2005-05-31 | 44 | 2005-01-03 | 2005-01-07 | 5d? | 11d |  |  |  | 224h |
| 52 | 1.2.1 | **Frame requirements** | 4d | 2005-04-20 | 2005-04-25 |  | 2005-01-03 | 2005-01-03 | 1d? | 23d | 0d |  |  | 32h |
| 53 | 1.2.1.1 | Equipment mounts, brackets, etc. | 1d | 2005-04-20 | 2005-04-20 |  | 2005-01-03 | 2005-01-03 | 1d? | 23d | 0d |  | Engineer - Mechanical-1 | 8h |
| 54 | 1.2.1.2 | Latch requirements | 1d | 2005-04-21 | 2005-04-21 | 53 | 2005-01-03 | 2005-01-03 | 1d? | 23d | 0d |  | Engineer - Mechanical-1 | 8h |
| 55 | 1.2.1.3 | Requirements document | 2d | 2005-04-22 | 2005-04-25 | 54 | 2005-01-03 | 2005-01-03 | 1d? | 23d |  |  | Engineer - Mechanical-1 | 16h |

| ID | WBS | Task | Type | Duration | Start | Finish | Predecessors | Baseline start | Baseline finish | Baseline duration | Total slack | Free slack | Constraint | Resources | Work | Cost | Baseline cost |
| --- | --- | --- | --- | --- | --- | --- | --- | --- | --- | --- | --- | --- | --- | --- | --- | --- | --- |
| 56 | 1.2.2 | **VB requirements** |  | 9d | 2005-04-26 | 2005-05-06 | 52 | 2005-01-03 | 2005-01-07 | 5d | 23d | 0d |  |  | 72h |  |  |
| 57 | 1.2.2.1 | Pump review |  | 4d | 2005-04-26 | 2005-04-29 |  | 2005-01-03 | 2005-01-07 | 5d | 23d | 0d |  | Engineer - Mechanical-1 | 32h |  |  |
| 58 | 1.2.2.2 | Sphere review |  | 3d | 2005-05-02 | 2005-05-04 | 57 | 2005-01-03 | 2005-01-07 | 5d | 23d | 0d |  | Engineer - Mechanical-1 | 24h |  |  |
| 59 | 1.2.2.3 | Block diagram |  | 2d | 2005-05-05 | 2005-05-06 | 58 | 2005-05-05 | 2005-05-06 | 2d | 23d |  |  | Engineer - Associate | 16h |  |  |
| 60 | 1.2.3 | **Payload requirements** |  | 17d | 2005-05-09 | 2005-05-31 | 56 | 2005-01-03 | 2005-01-03 | 1d? | 16d |  |  |  | 96h |  |  |
| 61 | 1.2.3.1 | **Weights (in air/water)** |  | 10d | 2005-05-09 | 2005-05-20 |  | 2005-01-03 | 2005-01-03 | 1d? | 23d |  |  |  | 80h |  |  |
| 62 | 1.2.3.1.1 | Spread sheet for weights (in air/water |  | 10d | 2005-05-09 | 2005-05-20 |  | 2005-01-03 | 2005-01-03 | 1d? | 23d |  |  | Engineer - Mechanical-1 | 80h |  |  |
| 63 | 1.2.3.2 | Foam pack |  | 2d | 2005-05-30 | 2005-05-31 |  | 2005-05-30 | 2005-05-31 | 2d | 16d |  |  | Engineer - Mechanical-1 | 16h |  |  |
| 64 | 1.2.4 | Frame, buoyancy & payload PDR |  | 2d | 2005-05-18 | 2005-05-19 |  | 2005-01-03 | 2005-01-03 | 1d? | 24d |  | start no earlier than 2005-05-18 | Engineer - Mechanical-1; DMO - Tiburon Support | 16h |  |  |
| 65 | 1.2.5 | **Crane base modifications** |  | 1d | 2005-05-05 | 2005-05-05 |  | 2005-05-05 | 2005-05-05 | 1d | 0d |  |  |  | 8h |  |  |
| 66 | 1.2.5.1 | Requirements Document |  | 1d | 2005-05-05 | 2005-05-05 |  | 2005-01-03 | 2005-01-03 | 1d? | 0d |  |  | Engineer - Mechanical-1 | 8h |  |  |
| 67 | 1.3 | Detailed specifications document |  | 6d | 2005-05-06 | 2005-05-13 | 66 | 2005-01-03 | 2005-01-03 | 1d? | 0d |  |  | Engineer - Electrical-1; Engineer - Mechanical-1; DMO - Tiburon Support; Engineer - Software | 160h |  |  |
| 68 | 1.4 | System engineering complete (milestone 1) | milestone | 0d | 2005-05-13 | 2005-05-13 | 67 | 2005-05-13 | 2005-05-13 | 0d? | 0d |  |  |  |  |  |  |
| 69 | 1.5 | Request for RFQ |  | 4w | 2005-05-16 | 2005-06-10 | 68 | 2005-01-04 | 2005-01-24 | 3w | 0d |  |  |  |  |  |  |
| 70 | 1.6 | Review RFQ (milestone 2) | milestone | 1.6w | 2005-06-13 | 2005-06-22 | 69 | 2005-01-25 | 2005-02-07 | 2w | 0d |  |  | Engineer - Electrical-1 [50%]; Engineer - Mechanical-1 [50%]; DMO - Tiburon Support [25%]; Engineer - Software [25%] | 60h |  |  |
| 71 | 2 | **Stage 2 - Design** |  | 77d | 2005-06-23 | 2005-10-07 | 70, 1 | 2005-02-08 | 2005-02-21 | 10d? | 0d |  |  |  | 991.51h | 1,760 | 1,760 |
| 72 | 2.1 | **Surface control systems** |  | 13d | 2005-06-23 | 2005-07-11 |  | 2005-02-08 | 2005-02-08 | 1d? | 0d |  |  |  | 250h |  |  |
| 73 | 2.1.1 | Nav Proc upgrade |  | 5d | 2005-06-23 | 2005-06-29 |  | 2005-02-08 | 2005-02-08 | 1d? | 0d |  |  | Engineer - Software | 40h |  |  |
| 74 | 2.1.2 | Data systems (logging) |  | 5d | 2005-06-30 | 2005-07-06 | 73 | 2005-02-08 | 2005-02-08 | 1d? | 0d |  |  | Engineer - Software | 40h |  |  |
| 75 | 2.1.3 | CTD Display |  | 3d | 2005-07-07 | 2005-07-11 | 74 | 2005-07-07 | 2005-07-11 | 3d | 0d |  |  | Engineer - Software; DMO CTD tech | 48h |  |  |
| 76 | 2.1.4 | Advanced control systems |  | 2d | 2005-06-23 | 2005-06-24 |  | 2005-06-23 | 2005-06-24 | 2d | 3d | 0d |  | Engineer - Support | 16h |  |  |
| 77 | 2.1.5 | Pilot console (joy sticks, etc.) |  | 5d | 2005-06-27 | 2005-07-01 | 76 | 2005-06-27 | 2005-07-01 | 5d | 3d | 0d |  | Engineer - Electrical-1 | 40h |  |  |
| 78 | 2.1.6 | CDR |  | 3d | 2005-07-04 | 2005-07-06 | 77 | 2005-07-04 | 2005-07-06 | 3d | 3d |  |  | Engineer - Electrical-1; Engineer - Mechanical-1 [50%]; Engineer - Software; DMO - Tiburon Support [25%] | 66h |  |  |
| 79 | 2.2 | **Tool sled controller** |  | 6d | 2005-07-12 | 2005-07-19 | 72 | 2005-02-08 | 2005-02-08 | 1d? | 0d |  |  |  | 164h |  |  |
| 80 | 2.2.1 | **Mux, power, I/O systems** |  | 4d | 2005-07-12 | 2005-07-15 |  | 2005-07-12 | 2005-07-15 | 4d | 0d |  |  |  | 128h |  |  |
| 81 | 2.2.1.1 | Housing & packaging |  | 4d | 2005-07-12 | 2005-07-15 |  | 2005-07-12 | 2005-07-15 | 4d | 0d |  |  | Engineer - Mechanical-1; DMO - Tiburon Support | 64h |  |  |
| 82 | 2.2.1.2 | Electrical design |  | 4d | 2005-07-12 | 2005-07-15 | 81SS | 2005-07-12 | 2005-07-15 | 4d | 0d |  |  | Engineer - Electrical-1; DMO - Tiburon Support | 64h |  |  |
| 83 | 2.2.2 | CDR |  | 2d | 2005-07-18 | 2005-07-19 | 80 | 2005-07-18 | 2005-07-19 | 2d | 0d |  |  | Engineer - Electrical-1; Engineer - Mechanical-1; DMO - Tiburon Support [25%] | 36h |  |  |

| ID | WBS | Task | Type | Duration | Start | Finish | Predecessors | Baseline start | Baseline finish | Baseline duration | Total slack | Free slack | Resources | Work | Cost | Baseline cost |
| --- | --- | --- | --- | --- | --- | --- | --- | --- | --- | --- | --- | --- | --- | --- | --- | --- |
| 84 | 2.3 | **Camera & viewing systems** |  | 19d | 2005-07-20 | 2005-08-15 | 79 | 2005-07-20 | 2005-08-15 | 19d | 0d |  |  | 249.51h |  |  |
| 85 | 2.3.1 | Camera, pan & tilt systems |  | 10d | 2005-07-20 | 2005-08-02 |  | 2005-07-20 | 2005-08-02 | 10d | 0d |  | Engineer - Mechanical-1 [50%]; Engineer - Electrical-1; DMO - Tiburon Support [25%] | 140h |  |  |
| 86 | 2.3.2 | Lap boxes |  | 1.5w | 2005-07-20 | 2005-07-29 | 85SS | 2005-07-20 | 2005-07-29 | 1.5w | 0d |  | Engineer - Electrical-1; Engineer - Mechanical-1 [50%]; DMO - Tiburon Support [25%]; Science [10%] | 34.6h |  |  |
| 87 | 2.3.3 | Iview control |  | 2w | 2005-07-20 | 2005-08-11 | 86SS | 2005-07-20 | 2005-08-11 | 2w | 0d |  | Engineer - Software; DMO - Tiburon Support [25%]; Engineer - Electrical-1; Engineer - Mechanical-1 [25%] | 42.91h |  |  |
| 88 | 2.3.4 | CDR |  | 2d | 2005-08-12 | 2005-08-15 | 87 | 2005-08-12 | 2005-08-15 | 2d | 0d |  | Engineer - Electrical-1; Engineer - Software | 32h |  |  |
| 89 | 2.4 | **Frame, buoyancy & payload** |  | 39d | 2005-08-16 | 2005-10-07 | 84 | 2005-02-08 | 2005-02-21 | 10d? | 0d |  |  | 328h | 1,760 | 1,760 |
| 90 | 2.4.1 | **Frame design** |  | 28d | 2005-08-16 | 2005-09-22 |  | 2005-02-08 | 2005-02-21 | 10d? | 0d |  |  | 224h |  |  |
| 91 | 2.4.1.1 | Core frame design |  | 2w | 2005-08-16 | 2005-08-29 |  | 2005-02-08 | 2005-02-21 | 2w | 0d |  | Engineer - Mechanical-1 | 80h |  |  |
| 92 | 2.4.1.2 | Vehicle latch design |  | 1w | 2005-08-30 | 2005-09-05 | 91 | 2005-02-08 | 2005-02-14 | 1w | 0d |  | Engineer - Mechanical-1 | 40h |  |  |
| 93 | 2.4.1.3 | Umbilical termination j-box |  | 1w | 2005-09-06 | 2005-09-12 | 92 | 2005-02-08 | 2005-02-14 | 1w | 0d |  | Engineer - Mechanical-1 | 40h |  |  |
| 94 | 2.4.1.4 | Brackets, mounts and hardware |  | 5d | 2005-09-13 | 2005-09-19 | 93 | 2005-02-08 | 2005-02-08 | 1d? | 0d |  | Engineer - Mechanical-1 | 40h |  |  |
| 95 | 2.4.1.5 | 3D Model subsystems |  | 3d | 2005-09-20 | 2005-09-22 | 94 | 2005-09-20 | 2005-09-22 | 3d | 0d |  | Engineer - Mechanical-1 | 24h |  |  |
| 96 | 2.4.2 | **VB system design** |  | 3d | 2005-09-23 | 2005-09-27 | 90 | 2005-02-08 | 2005-02-08 | 1d? | 0d |  |  | 24h |  |  |
| 97 | 2.4.2.1 | System design |  | 2d | 2005-09-23 | 2005-09-26 |  | 2005-09-23 | 2005-09-26 | 2d | 0d |  | Engineer - Mechanical-1 | 16h |  |  |
| 98 | 2.4.2.2 | Level feed back |  | 1d | 2005-09-27 | 2005-09-27 | 97 | 2005-09-27 | 2005-09-27 | 1d | 0d |  | Engineer - Electrical-1 | 8h |  |  |
| 99 | 2.4.3 | **Foam pack** |  | 5d | 2005-09-28 | 2005-10-04 | 96 | 2005-02-08 | 2005-02-08 | 1d? | 0d |  |  | 40h |  |  |
| 100 | 2.4.3.1 | Foam pack design |  | 1w | 2005-09-28 | 2005-10-04 |  | 2005-02-08 | 2005-02-08 | 1d? | 0d |  | Engineer - Mechanical-1 | 40h |  |  |
| 101 | 2.4.4 | **Crane base modifications** |  | 2d | 2005-08-16 | 2005-08-17 |  | 2005-01-03 | 2005-01-03 | 1d? | 37d |  |  | 16h | 1,760 | 1,760 |
| 102 | 2.4.4.1 | Out side services |  | 2d | 2005-08-16 | 2005-08-17 |  | 2005-08-16 | 2005-08-17 | 2d | 37d |  | Naval architect | 16h | 1,760 | 1,760 |
| 103 | 2.4.5 | CDR |  | 2d | 2005-10-05 | 2005-10-06 | 99 | 2005-10-05 | 2005-10-06 | 2d | 0d |  | Engineer - Mechanical-1 | 16h |  |  |
| 104 | 2.4.6 | RFQ for foam pack |  | 1d | 2005-10-07 | 2005-10-07 | 103 | 2005-10-07 | 2005-10-07 | 1d | 0d |  | Engineer - Mechanical-1 | 8h |  |  |
| 105 | 3 | System Design complete (milestone 3) | milestone | 0d | 2005-10-07 | 2005-10-07 | 104 | 2005-10-07 | 2005-10-07 | 0d? | 34d |  |  |  |  |  |
| 106 | 4 | **Stage 3 - 1st year development** |  | 34d | 2005-10-10 | 2005-11-24 | 71 | 2005-10-10 | 2005-11-24 | 34d | 0d |  |  | 841.72h | 391,000 | 391,000 |
| 107 | 4.1 | **Surface control system** |  | 18d | 2005-10-10 | 2005-11-02 |  | 2005-10-10 | 2005-11-02 | 18d | 16d |  |  | 93.72h | 111,000 | 111,000 |
| 108 | 4.1.1 | Purchase Surface control system |  | 1d | 2005-10-10 | 2005-10-10 |  | 2005-10-10 | 2005-10-10 | 1d | 16d | 0d | Surface control system |  | 96,000 | 96,000 |
| 109 | 4.1.2 | Belly pack controls (purchase) |  | 1d | 2005-10-11 | 2005-10-11 | 108 | 2005-10-11 | 2005-10-11 | 1d | 16d | 0d | Belly pack |  | 15,000 | 15,000 |
| 110 | 4.1.3 | Interface & test data systems |  | 6d | 2005-10-12 | 2005-10-19 | 109 | 2005-10-12 | 2005-10-19 | 6d | 16d | 0d | Engineer - Electrical-1 [50%]; Engineer - Software; DMO - Tiburon Support [10%]; DMO CTD tech [10%] | 13.72h |  |  |
| 111 | 4.1.4 | Advanced control systems |  | 2w | 2005-10-20 | 2005-11-02 | 110 | 2005-10-20 | 2005-11-02 | 2w | 16d |  | Engineer - Support | 80h |  |  |

| ID | WBS | Task | Type | Duration | Start | Finish | Predecessors | Baseline start | Baseline finish | Baseline duration | Total slack | Free slack | Resources | Work | Cost | Baseline cost |
| --- | --- | --- | --- | --- | --- | --- | --- | --- | --- | --- | --- | --- | --- | --- | --- | --- |
| 112 | 4.2 | **Toolsled controller** |  | 11d | 2005-10-10 | 2005-10-24 |  | 2005-10-10 | 2005-10-24 | 11d | 23d |  |  | 80h | 20,000 | 20,000 |
| 113 | 4.2.1 | Purchase tool sled controller |  | 1d | 2005-10-10 | 2005-10-10 |  | 2005-10-10 | 2005-10-10 | 1d | 23d | 0d | Tool sled componets |  | 20,000 | 20,000 |
| 114 | 4.2.2 | integrate tool sled controller |  | 1.4w | 2005-10-11 | 2005-10-24 | 113 | 2005-10-11 | 2005-10-24 | 1.4w | 23d |  | Engineer - Associate; Engineer - Machinist | 80h |  |  |
| 115 | 4.3 | **Camera & viewing** |  | 34d | 2005-10-10 | 2005-11-24 |  | 2005-10-10 | 2005-11-24 | 34d | 0d |  |  | 452h | 20,000 | 20,000 |
| 116 | 4.3.1 | Purchase hardware |  | 1d | 2005-10-10 | 2005-10-10 |  | 2005-10-10 | 2005-10-10 | 1d | 0d |  | Engineer - Electrical-1; Camera hardware | 8h | 20,000 | 20,000 |
| 117 | 4.3.2 | Lap box interface |  | 2w | 2005-10-11 | 2005-10-24 | 116 | 2005-10-11 | 2005-10-24 | 2w | 0d |  | Engineer - Electrical-1; Engineer - Software; DMO - Tiburon Support | 176h |  |  |
| 118 | 4.3.3 | Modified IVIEW control system |  | 2w | 2005-10-28 | 2005-11-10 | 117 | 2005-10-28 | 2005-11-10 | 2w | 0d |  | Engineer - Software; Engineer - Electrical-1; Engineer - Mechanical-1 [25%] | 180h |  |  |
| 119 | 4.3.4 | Integration & test |  | 2w | 2005-11-11 | 2005-11-24 | 118 | 2005-11-11 | 2005-11-24 | 2w | 0d |  | Engineer - Electrical-1; Engineer - Machinist | 88h |  |  |
| 120 | 4.4 | **Frame, buoyancy & payload** |  | 18d | 2005-10-10 | 2005-11-02 |  | 2005-10-10 | 2005-11-02 | 18d | 16d |  |  | 216h | 240,000 | 240,000 |
| 121 | 4.4.1 | Final frame & foam pack design |  | 2d | 2005-10-10 | 2005-10-11 |  | 2005-10-10 | 2005-10-11 | 2d | 16.48d | 0d | Engineer - Mechanical-1 | 16h |  |  |
| 122 | 4.4.2 | Purchase VB spheres |  | 1d | 2005-10-13 | 2005-10-13 | 121 | 2005-10-13 | 2005-10-13 | 1d | 16.48d | 0d | VB spheres; Engineer - Mechanical-1 | 8h | 35,000 | 35,000 |
| 123 | 4.4.3 | Fabricate & test VB system |  | 2.2w | 2005-10-14 | 2005-11-01 | 122 | 2005-10-14 | 2005-11-01 | 2.2w | 16.48d | 0d | Engineer - Mechanical-1; Engineer - Machinist; DMO - Tiburon Support | 120h |  |  |
| 124 | 4.4.4 | Purchase foam |  | 1d | 2005-11-01 | 2005-11-02 | 123 | 2005-11-01 | 2005-11-02 | 1d | 16.48d |  | Foam; Engineer - Mechanical-1 | 8h | 150,000 | 150,000 |
| 125 | 4.4.5 | **Crane base modifications** |  | 14d | 2005-10-14 | 2005-11-02 |  | 2005-10-14 | 2005-11-02 | 14d | 16d |  |  | 64h | 55,000 | 55,000 |
| 126 | 4.4.5.1 | Purchase materials for mods |  | 1d | 2005-10-14 | 2005-10-14 |  | 2005-10-14 | 2005-10-14 | 1d | 16d | 0d | Crane base mods; Engineer - Mechanical-1 | 8h | 10,000 | 10,000 |
| 127 | 4.4.5.2 | Purchase winch |  | 1d | 2005-10-18 | 2005-10-18 | 126 | 2005-10-18 | 2005-10-18 | 1d | 16d | 0d | Crane winch; Engineer - Mechanical-1 | 8h | 35,000 | 35,000 |
| 128 | 4.4.5.3 | Purchase lift lines |  | 1d | 2005-10-26 | 2005-10-26 | 127 | 2005-10-26 | 2005-10-26 | 1d | 16d | 0d | Lift lines; Engineer - Mechanical-1 | 8h | 10,000 | 10,000 |
| 129 | 4.4.5.4 | Perform modifications |  | 1w | 2005-10-27 | 2005-11-02 | 128 | 2005-10-27 | 2005-11-02 | 1w | 16d | 0d | Engineer - Machinist | 40h |  |  |
| 130 | 5 | 1st year development complete (milestone 4) | milestone | 0d | 2005-11-02 | 2005-11-02 | 129 | 2005-11-02 | 2005-11-02 | 0d? | 16d |  |  |  |  |  |
